# DP00

Schedule from MS Project, 2000-06-06 to 2001-03-30, status date 2000-06-05.
Drexel University

## Calendars

- Standard: Mon-Fri 08:00-12:00, 13:00-17:00; Sat-Sun off.

## Resources

| Resource |
| --- |
| 0 |
| 12 |
| 1 |
| 9 |
| 4 |
| 32 |
| 8 |
| 2 |
| 5 |
| 78 |
| 10 |
| 43 |
| 33 |
| 25 |
| 13 |
| 28 |
| 18 |
| 30 |
| 29 |
| 14 |
| 19 |
| 62 |
| 20 |
| 23 |
| 11 |
| 15 |
| 73 |
| 63 |
| 68 |
| 48 |
| 44 |
| 46 |
| 34 |
| 37 |
| OP |
| SV |
| PB |
| CP |
| EL |
| BM |
| IW |
| LB |
| RF |
| PF |
| ST |
| SM |
| PA |
| IN |
| TL |
| MA |
| GZ |

## Schedule

| ID | WBS | Task | Duration | Start | Finish | Predecessors | Total slack | Free slack | Constraint | Resources | Work | Text1 | Text3 |
| --- | --- | --- | --- | --- | --- | --- | --- | --- | --- | --- | --- | --- | --- |
| 1 | 1 | START OF NETWORK | 1d | 2000-06-06 | 2000-06-06 |  | 0d |  | start no earlier than 2000-06-05 |  |  | 0 |  |
| 2 | 2 | END OF NETWORK | 1d | 2001-03-30 | 2001-03-30 | 63, 102, 115, 127, 130, 131, 137, 138, 143 | 0d |  |  |  |  | 80 |  |
| 3 | 3 | CLEAR SITE | 3d | 2000-06-07 | 2000-06-09 | 1 | 0d |  |  | OP | 24h | 0 1 |  |
| 4 | 4 | SUBMIT FOUNDATION REBAR | 10d | 2000-06-07 | 2000-06-20 | 1 | 183d | 0d |  |  |  | 0 210 |  |
| 5 | 5 | SUBMIT STRUCTURAL STEEL | 20d | 2000-06-07 | 2000-07-04 | 1 | 38d | 0d |  |  |  | 0 212 |  |
| 6 | 6 | SUBMIT CRANE | 20d | 2000-06-07 | 2000-07-04 | 1 | 23d | 0d |  |  |  | 0 214 |  |
| 7 | 7 | SUBMIT BAR JOISTS | 20d | 2000-06-07 | 2000-07-04 | 1 | 48d | 0d |  |  |  | 0 216 |  |
| 8 | 8 | SUBMIT SIDING | 20d | 2000-06-07 | 2000-07-04 | 1 | 44d | 0d |  |  |  | 0 218 |  |
| 9 | 9 | SUBMIT PLANT ELECTRICAL LOAD CENTER | 20d | 2000-06-07 | 2000-07-04 | 1 | 4d | 0d |  |  |  | 0 220 |  |
| 10 | 10 | SUBMIT POWER PANELS - PLANT | 20d | 2000-06-07 | 2000-07-04 | 1 | 31d | 0d |  |  |  | 0 222 |  |
| 11 | 11 | SUBMIT EXTERIOR DOORS | 20d | 2000-06-07 | 2000-07-04 | 1 | 37d | 0d |  |  |  | 0 224 |  |
| 12 | 12 | SUBMIT PLANT ELECTRICAL FIXTURES | 30d | 2000-06-07 | 2000-07-18 | 1 | 37d | 0d |  |  |  | 0 225 |  |
| 13 | 13 | SUBMIT PLANT HEATING AND VENTILATING FANS | 20d | 2000-06-07 | 2000-07-04 | 1 | 42d | 0d |  |  |  | 0 227 |  |
| 14 | 14 | SUBMIT BOILER | 20d | 2000-06-07 | 2000-07-04 | 1 | 77d | 0d |  |  |  | 0 229 |  |
| 15 | 15 | SUBMIT OIL TANK | 20d | 2000-06-07 | 2000-07-04 | 1 | 130d | 0d |  |  |  | 0 231 |  |
| 16 | 16 | SUBMIT PRECAST | 40d | 2000-06-07 | 2000-08-01 | 1 | 48d | 0d |  |  |  | 0 233 |  |
| 17 | 17 | SUBMIT PACKAGED A/C | 30d | 2000-06-07 | 2000-07-18 | 1 | 8d | 0d |  |  |  | 0 235 |  |
| 18 | 18 | SURVEY AND LAYOUT | 2d | 2000-06-12 | 2000-06-13 | 3 | 0d |  |  | SV | 16h | 1 2 |  |
| 19 | 19 | ROUGH GRADE | 2d | 2000-06-14 | 2000-06-15 | 18 | 0d |  |  | OP | 16h | 2 3 |  |
| 20 | 20 | DRILL WELL | 15d | 2000-06-16 | 2000-07-06 | 19 | 0d |  |  | PB | 120h | 3 4 |  |
| 21 | 21 | WATER TANK FOUNDATIONS | 4d | 2000-06-16 | 2000-06-21 | 19 | 1d | 0d |  | CP | 32h | 3 6 |  |
| 22 | 22 | EXCAVATE FOR SEWER | 10d | 2000-06-16 | 2000-06-29 | 19 | 4d | 0d |  | OP | 80h | 3 9 |  |
| 23 | 23 | EXCAVATE ELECTRIC MANHOLES | 1d | 2000-06-16 | 2000-06-16 | 19 | 13d | 0d |  | OP | 8h | 3 10 |  |
| 24 | 24 | OVERHEAD POLE LINE | 6d | 2000-06-16 | 2000-06-23 | 19 | 16d | 12d |  | EL | 48h | 3 12 |  |
| 25 | 25 | INSTALL WELL PUMP | 2d | 2000-07-07 | 2000-07-10 | 20 | 0d |  |  | PB | 16h | 4 5 |  |
| 26 | 26 | UNDERGROUND WATER PIPING | 8d | 2000-07-11 | 2000-07-20 | 25 | 0d |  |  | PB | 64h | 5 8 |  |
| 27 | 27 | ERECT WATER TANK | 10d | 2000-06-22 | 2000-07-05 | 21 | 1d | 0d |  | BM | 80h | 6 7 | 10 |
| 28 | 28 | TANK PIPING & VALVES | 10d | 2000-07-06 | 2000-07-19 | 27 | 1d |  |  | BM | 80h | 7 8 | 10 |
| 29 | 29 | CONNECT WATER PIPING | 2d | 2000-07-21 | 2000-07-24 | 26, 28 | 0d |  |  | BM | 16h | 8 13 | 10 |
| 30 | 30 | INSTALL SEWER AND BACKFILL | 5d | 2000-06-30 | 2000-07-06 | 22 | 4d | 0d |  | PB | 40h | 9 11 |  |
| 31 | 31 | INSTALL ELECTRICAL MANHOLES | 5d | 2000-06-19 | 2000-06-23 | 23 | 13d | 9d |  | CP | 40h | 10 11 |  |
| 32 | 32 | INSTALL ELECTRICAL DUCT BANK | 3d | 2000-07-07 | 2000-07-11 | 30, 31 | 4d | 0d |  | EL | 24h | 11 12 |  |
| 33 | 33 | PULL IN FEEDER | 5d | 2000-07-12 | 2000-07-18 | 24, 32 | 4d |  |  | EL | 40h | 12 13 |  |
| 34 | 34 | BUILDING LAYOUT | 1d | 2000-07-25 | 2000-07-25 | 29, 33 | 0d |  |  | SV | 8h | 13 14 |  |
| 35 | 35 | DRIVE AND POUR PILES | 10d | 2000-07-26 | 2000-08-08 | 34 | 0d |  |  | OP | 80h | 14 15 | 11 |
| 36 | 36 | EXCAVATE FOR OFFICE BUILDING | 3d | 2000-07-26 | 2000-07-28 | 34 | 70d | 32d |  | OP | 24h | 14 23 |  |
| 37 | 37 | EXCAVATE PLANT WAREHOUSE | 5d | 2000-08-09 | 2000-08-15 | 35 | 0d |  |  | OP | 40h | 15 16 |  |
| 38 | 38 | POUR PILE CAPS P-W | 5d | 2000-08-16 | 2000-08-22 | 37 | 0d |  |  | CP | 40h | 16 17 |  |
| 39 | 39 | FORM AND POUR GRADE BEAMS P-W | 10d | 2000-08-23 | 2000-09-05 | 38 | 0d |  |  | CP | 80h | 17 18 |  |
| 40 | 40 | BACKFILL AND COMPACT P-W | 3d | 2000-09-06 | 2000-09-08 | 39 | 0d |  |  | OP | 24h | 18 19 |  |
| 41 | 41 | FORM AND POUR RAILROAD LOADING DOCK P-W | 5d | 2000-09-06 | 2000-09-12 | 39 | 8d | 0d |  | CP | 40h | 18 21 |  |
| 42 | 42 | FORM AND POUR TRUCK LOADING DOCK P-W | 5d | 2000-09-06 | 2000-09-12 | 39 | 8d |  |  | CP | 40h | 18 22 |  |
| 43 | 43 | UNDERSLAB PLUMBING P-W | 5d | 2000-09-11 | 2000-09-15 | 40 | 0d |  |  | PB | 40h | 19 20 |  |
| 44 | 44 | UNDERSLAB CONDUIT P-W | 5d | 2000-09-18 | 2000-09-22 | 43 | 0d |  |  | EL | 40h | 20 22 |  |
| 46 | 45 | FORM AND POUR SLABS P-W | 10d | 2000-09-25 | 2000-10-06 | 42, 44 | 0d |  |  | CP | 80h | 22 29 |  |
| 47 | 46 | SPREAD FOOTINGS OFFICE | 4d | 2000-09-13 | 2000-09-18 | 36, 148 | 38d | 0d |  | CP | 32h | 23 24 |  |
| 48 | 47 | FORM AND POUR GRADE BEAMS OFFICE | 6d | 2000-09-19 | 2000-09-26 | 47 | 38d | 0d |  | CP | 48h | 24 25 |  |
| 49 | 48 | BACKFILL AND COMPACT OFFICE | 1d | 2000-09-27 | 2000-09-27 | 48 | 38d | 0d |  | OP | 8h | 25 26 |  |
| 50 | 49 | UNDERSLAB PLUMBING OFFICE | 3d | 2000-09-28 | 2000-10-02 | 49 | 38d | 0d |  | PB | 24h | 26 27 |  |
| 51 | 50 | UNDERSLAB CONDUIT OFFICE | 3d | 2000-10-03 | 2000-10-05 | 50 | 38d | 0d |  | CP | 24h | 27 28 |  |
| 52 | 51 | FORM AND POUR SLABS OFFICE | 3d | 2000-10-06 | 2000-10-10 | 51 | 38d | 0d |  | CP | 24h | 28 99 |  |
| 53 | 52 | ERECT STRUCTURAL STEEL P-W | 10d | 2000-10-09 | 2000-10-20 | 46 | 0d |  |  | OP | 80h | 29 30 |  |
| 54 | 53 | PLUMB AND BOLT STEEL P-W | 5d | 2000-10-23 | 2000-10-27 | 53 | 0d |  |  | OP | 40h | 30 31 |  |
| 55 | 54 | ERECT CRANEWAY AND CRANE P-W | 5d | 2000-10-30 | 2000-11-03 | 54, 150 | 0d |  |  | IW | 40h | 31 32 |  |
| 56 | 55 | ERECT MONORAIL TRACK P-W | 3d | 2000-10-30 | 2000-11-01 | 54, 150 | 2d |  |  | IW | 24h | 31 33 |  |
| 58 | 56 | ERECT BAR JOISTS P-W | 3d | 2000-11-06 | 2000-11-08 | 56, 152 | 0d |  |  | OP | 24h | 33 34 |  |
| 59 | 57 | ERECT ROOF PLANKS P-W | 3d | 2000-11-09 | 2000-11-13 | 58 | 0d |  |  | LB | 24h | 34 35 |  |
| 60 | 58 | ERECT SIDING P-W | 10d | 2000-11-14 | 2000-11-27 | 59, 154 | 0d |  |  | OP | 80h | 35 36 | 12 |
| 61 | 59 | BUILT-UP ROOFING P-W | 5d | 2000-11-14 | 2000-11-20 | 59, 154 | 5d |  |  | RF | 40h | 35 37 | 13 |
| 63 | 60 | PERIMETER FENCE | 10d | 2000-11-28 | 2000-12-11 | 61 | 78d |  |  | LB | 80h | 37 80 | 15 |
| 64 | 61 | PAVE PARKING AREA | 5d | 2000-11-28 | 2000-12-04 | 61 | 73d | 0d |  | OP | 40h | 37 90 | 16 |
| 65 | 62 | GRADE AND BALLAST RAILROAD SIDING | 5d | 2000-11-28 | 2000-12-04 | 61 | 63d | 0d |  | OP | 40h | 37 91 | 17 |
| 66 | 63 | ACCESS ROAD | 10d | 2000-11-28 | 2000-12-11 | 61 | 68d | 0d |  | OP | 80h | 37 92 | 16 |
| 67 | 64 | AREA LIGHTING | 20d | 2000-11-28 | 2000-12-25 | 61 | 68d | 0d |  | EL | 160h | 37 93 |  |
| 77 | 65 | INSTALL POWER CONDUIT P-W | 20d | 2000-11-30 | 2000-12-27 | 173 | 0d |  |  | EL | 160h | 38 43 |  |
| 78 | 66 | FRAME CEILING P-W | 5d | 2000-12-12 | 2000-12-18 | 176 | 13d | 0d |  | CP | 40h | 39 42 | 18 |
| 79 | 67 | TEST PIPING SYSTEMS P-W | 10d | 2001-01-09 | 2001-01-22 | 180 | 33d | 0d |  | PF | 80h | 40 47 |  |
| 80 | 68 | PREOPERATIONAL CHECK | 5d | 2001-01-02 | 2001-01-08 | 179 | 43d | 10d |  | ST | 40h | 41 47 |  |
| 81 | 69 | DRYWALL PARTITIONS P-W | 10d | 2000-12-19 | 2001-01-01 | 78, 175 | 13d | 0d |  | CP | 80h | 42 44 | 19 |
| 82 | 70 | INSTALL BRANCH CONDUIT P-W | 15d | 2000-12-28 | 2001-01-17 | 77, 174 | 0d |  |  | EL | 120h | 43 49 |  |

| ID | WBS | Task | Duration | Start | Finish | Predecessors | Total slack | Free slack | Resources | Work | Text1 | Text3 |
| --- | --- | --- | --- | --- | --- | --- | --- | --- | --- | --- | --- | --- |
| 85 | 71 | CERAMIC TILE | 10d | 2001-01-02 | 2001-01-15 | 81 | 18d | 0d |  |  | 44 48 | 20 |
| 86 | 72 | HANG INTERIOR DOORS P-W | 10d | 2001-01-02 | 2001-01-15 | 81 | 43d |  | CP | 80h | 44 58 | 21 |
| 87 | 73 | ROOM OUTLETS P-W | 5d | 2001-01-18 | 2001-01-24 |  | 25d | 0d | EL | 40h | 45 51 |  |
| 88 | 74 | INSTALL DUCTWORK P-W | 25d | 2001-01-02 | 2001-02-05 | 177 | 13d | 0d | SM | 200h | 46 52 |  |
| 89 | 75 | LIGHT OFF BOILER AND TEST | 5d | 2001-01-23 | 2001-01-29 | 79, 80 | 33d |  | ST | 40h | 47 58 |  |
| 90 | 76 | PAINT ROOMS P-W | 5d | 2001-01-16 | 2001-01-22 | 85 | 18d | 0d | PA | 40h | 48 53 | 22 |
| 92 | 77 | PULL WIRE P-W | 15d | 2001-01-18 | 2001-02-07 | 82 | 0d |  | EL | 120h | 49 50 |  |
| 93 | 78 | INSTALL PANEL INTERNALS P-W | 5d | 2001-02-08 | 2001-02-14 | 92 | 0d |  | EL | 40h | 50 54 |  |
| 94 | 79 | INSTALL ELECTRICAL FIXTURES | 10d | 2001-01-25 | 2001-02-07 | 87, 162 | 25d |  | EL | 80h | 51 56 |  |
| 95 | 80 | INSULATE HEATING AND VENTILATING SYSTEM P-W | 15d | 2001-02-06 | 2001-02-26 | 88 | 13d |  | IN | 120h | 52 58 |  |
| 96 | 81 | FLOOR TILE P-W | 10d | 2001-01-23 | 2001-02-05 | 90 | 18d | 0d | TL | 80h | 53 57 | 22 |
| 97 | 82 | INSTALL PLUMBING FIXTURES P-W | 10d | 2001-01-23 | 2001-02-05 | 90 | 28d |  | PB | 80h | 53 58 |  |
| 98 | 83 | TERMINATE WIRE P-W | 10d | 2001-02-15 | 2001-02-28 | 93 | 0d |  | EL | 80h | 54 55 |  |
| 99 | 84 | RING OUT P-W | 10d | 2001-03-01 | 2001-03-14 | 98 | 0d |  | EL | 80h | 55 56 |  |
| 100 | 85 | ENERGIZE POWER | 1d | 2001-03-15 | 2001-03-15 | 94, 99 | 0d |  | EL | 8h | 56 58 |  |
| 101 | 86 | INSTALL FURNISHINGS P-W | 10d | 2001-02-06 | 2001-02-19 | 96 | 18d |  | LB | 80h | 57 58 | 24 |
| 102 | 87 | ERECT FLAGPOLE | 5d | 2001-03-16 | 2001-03-22 | 86, 89, 95, 97, 100, 101, 140, 181 | 5d |  | LB | 40h | 58 80 | 29 |
| 103 | 88 | FINE GRADE | 5d | 2001-03-16 | 2001-03-22 | 86, 89, 95, 97, 100, 101, 140, 181 | 0d |  | OP | 40h | 58 94 |  |
| 104 | 89 | ERECT PRECAST ROOF OFFICE | 5d | 2000-10-18 | 2000-10-24 | 144 | 38d | 30d | OP | 40h | 59 60 |  |
| 105 | 90 | EXTERIOR MASONRY OFFICE | 10d | 2000-12-06 | 2000-12-19 | 104, 172 | 8d | 0d | MA | 80h | 60 61 | 14 |
| 106 | 91 | INSTALL PACKAGE AIR CONDITIONING | 5d | 2000-12-06 | 2000-12-12 | 104, 172 | 68d | 29d | ST | 40h | 60 76 |  |
| 107 | 92 | EXTERIOR DOORS OFFICE | 5d | 2000-12-20 | 2000-12-26 | 105 | 22d | 0d | CP | 40h | 61 62 | 21 |
| 108 | 93 | PLACE SINGLE-PLY ROOFING OFFICE | 5d | 2000-12-20 | 2000-12-26 | 105 | 22d | 0d | RF | 40h | 61 63 | 17 |
| 109 | 94 | INSTALL PIPING OFFICE | 10d | 2000-12-20 | 2001-01-02 | 105 | 8d | 0d | PF | 80h | 61 64 |  |
| 110 | 95 | INSTALL BACKING BOXES | 4d | 2000-12-20 | 2000-12-25 | 105 | 8d | 0d | EL | 32h | 61 65 |  |
| 111 | 96 | GLAZE OFFICE | 5d | 2000-12-20 | 2000-12-26 | 105 | 22d | 14d | GZ | 40h | 61 68 | 25 |
| 112 | 97 | DUCTWORK OFFICE | 15d | 2000-12-20 | 2001-01-09 | 105 | 42d | 19d | SM | 120h | 61 77 |  |
| 115 | 98 | PAINT EXTERIOR OFFICE | 5d | 2000-12-27 | 2001-01-02 | 108 | 62d |  | PA | 40h | 63 80 | 22 |
| 116 | 99 | TEST PIPING OFFICE | 4d | 2001-01-03 | 2001-01-08 | 109 | 8d | 0d | PF | 32h | 64 67 |  |
| 117 | 100 | INSTALL CONDUIT OFFICE | 10d | 2000-12-26 | 2001-01-08 | 110 | 8d | 0d | EL | 80h | 65 66 |  |
| 119 | 101 | PULL WIRE OFFICE | 10d | 2001-01-09 | 2001-01-22 | 117 | 28d | 0d | EL | 80h | 66 74 |  |
| 120 | 102 | METAL STUDS OFFICE | 5d | 2001-01-09 | 2001-01-15 | 116 | 8d | 0d | CP | 40h | 67 68 | 19 |
| 121 | 103 | DRYWALL | 5d | 2001-01-16 | 2001-01-22 | 111, 120 | 8d | 0d | CP | 40h | 68 69 | 19 |
| 122 | 104 | DRYWALL | 10d | 2001-01-23 | 2001-02-05 | 121 | 8d | 0d | CP | 80h | 69 70 | 19 |
| 123 | 105 | CERAMIC TILE OFFICE | 10d | 2001-01-23 | 2001-02-05 | 121 | 33d | 20d | TL | 80h | 69 73 | 20 |
| 124 | 106 | WOOD TRIM OFFICE | 10d | 2001-02-06 | 2001-02-19 | 122 | 8d | 0d | CP | 80h | 70 71 | 26 |
| 126 | 107 | PAINT INTERIOR OFFICE | 10d | 2001-02-20 | 2001-03-05 | 124 | 8d | 0d | PA | 80h | 71 72 | 22 |
| 127 | 108 | HANG DOORS OFFICE | 5d | 2001-02-20 | 2001-02-26 | 124 | 23d |  | CP | 40h | 71 80 | 21 |
| 130 | 109 | FLOOR TILE OFFICE | 10d | 2001-03-06 | 2001-03-19 | 126 | 8d |  | TL | 80h | 72 80 | 20 |
| 131 | 110 | TOILET FIXTURES OFFICE | 5d | 2001-03-06 | 2001-03-12 | 123 | 13d |  | PB | 40h | 73 80 |  |
| 132 | 111 | INSTALL PANEL INTERNALS OFFICE | 5d | 2001-01-23 | 2001-01-29 | 119 | 28d | 0d | EL | 40h | 74 75 |  |
| 134 | 112 | TERMINATE WIRES OFFICE | 10d | 2001-01-30 | 2001-02-12 | 132 | 28d | 0d | EL | 80h | 75 79 |  |
| 135 | 113 | A/C ELECTRICAL CONNECTIONS | 4d | 2001-01-23 | 2001-01-26 | 106 | 39d | 11d | EL | 32h | 76 79 |  |
| 136 | 114 | INSTALL CEILING GRID OFFICE | 5d | 2001-02-06 | 2001-02-12 | 112 | 23d | 15d | CP | 40h | 77 78 | 18 |
| 137 | 115 | ACOUSTIC TILES OFFICE | 10d | 2001-03-06 | 2001-03-19 | 136 | 8d |  | CP | 80h | 78 80 | 18 |
| 138 | 116 | RING OUT | 5d | 2001-02-13 | 2001-02-19 | 134, 135 | 28d |  | EL | 40h | 79 80 |  |
| 140 | 117 | INSTALL RAILROAD SIDING | 10d | 2000-12-05 | 2000-12-18 | 65 | 63d |  | OP | 80h | 91 58 | 17 |
| 143 | 118 | SEED AND PLANT | 5d | 2001-03-23 | 2001-03-29 | 103 | 0d |  | LB | 40h | 94 80 | 27 |
| 144 | 119 | ERECT PRECAST STRUCTURE | 5d | 2000-10-11 | 2000-10-17 | 52, 170 | 38d | 0d | OP | 40h | 99 59 |  |
| 145 | 120 | APPROVE FOUNDATION REBAR | 10d | 2000-06-21 | 2000-07-04 | 4 | 183d | 0d |  |  | 210 211 |  |
| 146 | 121 | FAB/DEL FOUNDATION REBAR | 10d | 2000-07-05 | 2000-07-18 | 145 | 183d |  |  |  | 211 16 |  |
| 147 | 122 | APPROVE STRUCTURAL STEEL | 10d | 2000-07-05 | 2000-07-18 | 5 | 38d | 0d |  |  | 212 213 |  |
| 148 | 123 | FAB/DEL STRUCTURAL STEEL | 40d | 2000-07-19 | 2000-09-12 | 147 | 38d | 0d |  |  | 213 23 |  |
| 149 | 124 | APPROVE CRANE | 10d | 2000-07-05 | 2000-07-18 | 6 | 23d | 0d |  |  | 214 215 |  |
| 150 | 125 | FAB/DEL CRANE | 50d | 2000-07-19 | 2000-09-26 | 149 | 23d |  |  |  | 215 31 |  |
| 151 | 126 | APPROVE BAR JOISTS | 10d | 2000-07-05 | 2000-07-18 | 7 | 48d | 0d |  |  | 216 217 |  |
| 152 | 127 | FAB/DEL BAR JOISTS | 30d | 2000-07-19 | 2000-08-29 | 151 | 48d |  |  |  | 217 33 |  |
| 153 | 128 | APPROVE SIDING | 10d | 2000-07-05 | 2000-07-18 | 8 | 44d | 0d |  |  | 218 219 |  |
| 154 | 129 | FAB/DEL SIDING | 40d | 2000-07-19 | 2000-09-12 | 153 | 44d |  |  |  | 219 35 |  |
| 155 | 130 | APPROVE PLANT ELECTRICAL LOAD CENTER | 10d | 2000-07-05 | 2000-07-18 | 9 | 4d | 0d |  |  | 220 221 |  |
| 156 | 131 | FAB/DEL PLANT ELECTRICAL LOAD CENTER | 90d | 2000-07-19 | 2000-11-21 | 155 | 4d |  |  |  | 221 300 |  |
| 157 | 132 | APPROVE POWER PANELS - PLANT | 10d | 2000-07-05 | 2000-07-18 | 10 | 31d | 0d |  |  | 222 223 |  |
| 158 | 133 | FAB/DEL POWER PANELS - PLANT | 75d | 2000-07-19 | 2000-10-31 | 157 | 31d | 19d |  |  | 223 301 |  |
| 159 | 134 | APPROVE EXTERIOR DOORS | 10d | 2000-07-05 | 2000-07-18 | 11 | 37d | 0d |  |  | 224 225 |  |
| 160 | 135 | APPROVE PLANT ELECTRICAL FIXTURES | 15d | 2000-07-19 | 2000-08-08 | 12, 159 | 71d | 0d |  |  | 225 226 |  |
| 161 | 136 | FAB/DEL EXTERIOR DOORS | 80d | 2000-07-19 | 2000-11-07 | 12, 159 | 37d | 14d |  |  | 225 302 |  |
| 162 | 137 | FAB/DEL PLANT ELECTRICAL FIXTURES | 75d | 2000-08-09 | 2000-11-21 | 160 | 71d | 46d |  |  | 226 51 |  |
| 163 | 138 | APPROVE PLANT HEATING AND VENTILATING FANS | 10d | 2000-07-05 | 2000-07-18 | 13 | 42d | 0d |  |  | 227 228 |  |
| 164 | 139 | FAB/DEL PLANT HEATING AND VENTILATING FANS | 75d | 2000-07-19 | 2000-10-31 | 163 | 42d | 19d |  |  | 228 304 |  |
| 165 | 140 | APPROVE BOILER | 10d | 2000-07-05 | 2000-07-18 | 14 | 77d | 0d |  |  | 229 230 |  |

| ID | WBS | Task | Duration | Start | Finish | Predecessors | Total slack | Free slack | Resources | Work | Text1 | Text3 |
| --- | --- | --- | --- | --- | --- | --- | --- | --- | --- | --- | --- | --- |
| 166 | 141 | FAB/DEL BOILER | 60d | 2000-07-19 | 2000-10-10 | 165 | 77d | 34d |  |  | 230 306 |  |
| 167 | 142 | APPROVE OIL TANK | 10d | 2000-07-05 | 2000-07-18 | 15 | 130d | 0d |  |  | 231 232 |  |
| 168 | 143 | FAB/DEL OIL TANK | 50d | 2000-07-19 | 2000-09-26 | 167 | 130d | 44d |  |  | 232 305 |  |
| 169 | 144 | APPROVE PRECAST | 10d | 2000-08-02 | 2000-08-15 | 16 | 48d | 0d |  |  | 233 234 |  |
| 170 | 145 | FAB/DEL PRECAST | 30d | 2000-08-16 | 2000-09-26 | 169 | 48d | 10d |  |  | 234 99 |  |
| 171 | 146 | APPROVE PACKAGED A/C | 10d | 2000-07-19 | 2000-08-01 | 17 | 8d | 0d |  |  | 235 236 |  |
| 172 | 147 | FAB/DEL PACKAGED A/C | 90d | 2000-08-02 | 2000-12-05 | 171 | 8d | 0d |  |  | 236 60 |  |
| 173 | 148 | SET ELECTRICAL LOAD CENTER | 2d | 2000-11-28 | 2000-11-29 | 156 | 0d |  | EL | 16h | 300 38 |  |
| 174 | 149 | INSTALL POWER PANEL BACKING BOXES | 10d | 2000-11-28 | 2000-12-11 | 158 | 12d |  | EL | 80h | 301 43 |  |
| 175 | 150 | EXTERIOR DOORS P-W | 5d | 2000-11-28 | 2000-12-04 | 161 | 23d | 10d | CP | 40h | 302 42 |  |
| 176 | 151 | MASONRY PARTITIONS | 10d | 2000-11-28 | 2000-12-11 |  | 13d | 0d | MA | 80h | 303 39 | 14 |
| 177 | 152 | INSTALL HEATING AND VENTILATING UNITS | 15d | 2000-11-28 | 2000-12-18 | 164 | 23d | 10d | ST | 120h | 304 46 |  |
| 178 | 153 | INSTALL FUEL OIL TANK | 3d | 2000-11-28 | 2000-11-30 | 168 | 86d |  | ST | 24h | 305 47 |  |
| 179 | 154 | ERECT BOILERS AND AUXILIARIES | 25d | 2000-11-28 | 2001-01-01 | 166 | 43d | 0d | ST | 200h | 306 41 |  |
| 180 | 155 | FABRICATE PIPING SYSTEMS | 30d | 2000-11-28 | 2001-01-08 |  | 33d | 0d |  |  | 307 40 |  |
| 181 | 156 | INSTALL MONORAIL | 5d | 2000-11-28 | 2000-12-04 |  | 73d |  | IW | 40h | 308 58 |  |
